# 3GPP_Release-2000

Schedule from MS Project, 2000-01-03 to 2006-12-29, A marks actual dates.

## Calendars

- Standard: Mon-Fri 08:00-12:00, 13:00-17:00; Sat-Sun off.

## Resources

| Resource |
| --- |
| NP |
| N1 |
| N2 |
| N3 |
| N4 |
| N5 |
| TP |
| T1 |
| T2 |
| T3 |
| RP |
| R1 |
| R2 |
| R3 |
| R4 |
| SP |
| S1 |
| S2 |
| S3 |
| S4 |
| S5 |
| PCG |
| GP |
| No |
| CN4 |
| ? |
| WG G2 |
| G2 |
| G1 |
| G4 |
| G3 |
| All |
| Generic |
| MLST |
| G5 |
| S3; G2 |
| WG T2 |
| GP;G1 |
| G4;G5 |
| OMA |
| GP-G2 |
| Yes |
| GP; |
| N4; |
| GP; N1 |
| CT5 |
| C5 |
| C1 |
| C4 |
| C3 |
| C6 |
| G1; |

## Schedule

| ID | WBS | Task | Type | Duration | Start | Finish | Complete | Remaining | Baseline start | Baseline finish | Baseline duration | Total slack | Constraint | Resources | Work | Actual work | Text9 | Text6 | Text1 | Text3 | Text4 | Text5 | Text7 | Text8 | Text2 | Text12 |
| --- | --- | --- | --- | --- | --- | --- | --- | --- | --- | --- | --- | --- | --- | --- | --- | --- | --- | --- | --- | --- | --- | --- | --- | --- | --- | --- |
| 1 | 1 | VERSION 2005 September 15th |  | 1d | 2000-01-03 | 2000-01-03 |  |  | 2000-01-03 | 2000-01-03 | 1d | 1824d |  |  |  |  | 2044 |  |  |  |  |  |  |  |  |  |
| 2 | 2 | "CTRL + a" to display all the 3GPP fields |  | 1d | 2000-01-03 | 2000-01-03 |  |  | 2000-01-03 | 2000-01-03 | 1d | 1824d |  |  |  |  | 1462 |  |  |  |  |  |  |  |  |  |
| 3 | 3 | Content of Release 7, not frozen |  | 1d | 2000-01-03 | 2000-01-03 |  |  | 2000-01-03 | 2000-01-03 | 1d | 1824d |  |  |  |  | 2058 |  |  |  |  |  |  |  |  |  |
| 5 | 4 | Rel-7 Features listed below |  | 1d? | 2000-01-03 | 2000-01-03 |  |  | 2000-01-03 | 2000-01-03 | 1d? | 1824d |  |  |  |  |  | Rel-7 |  |  |  |  |  |  |  |  |
| 6 | 8.5 | **Multiple Input Multiple Output antennas (MIMO)** |  | 719d? | 2003-03-14 A | 2005-12-15 | 12% | 634.49d? | 2003-03-14 | 2005-12-15 | 719d? | 272d |  | R1 | 23544h | 4190.4h | 2468 | Rel-7 | MIMO | TR25.876,TR25.996 | Howard Huang, Lucent | hchuang@lucent.com | TSG | Cesar |  |  |
| 7 | 5.1 | MIMO - Physical layer |  | 392d? | 2003-09-12 A | 2005-03-15 | 60% | 156.8d? | 2003-09-12 | 2005-03-15 | 392d? | 469d | finish no earlier than 2005-03-15 | R1 | 3136h | 1881.6h |  | Rel-7 | MIMO-Phys | 25.211, 25.212, 25.213, 25.214, 25.215, 25.221, 25 | Howard Huang, Lucent | hchuang@lucent.com | TSG | Cesar |  |  |
| 8 | 5.2 | MIMO - Layer 2,3 aspects |  | 589d? | 2003-09-12 | 2005-12-15 |  |  | 2003-09-12 | 2005-12-15 | 589d? | 272d | finish no earlier than 2005-12-15 | R2 | 4712h |  |  | Rel-7 | MIMO-L23 | TR 25.876 | Howard Huang, Lucent | hchuang@lucent.com | TSG | Cesar |  |  |
| 9 | 5.3 | MIMO - Iub/Iur Protocol Aspects |  | 719d? | 2003-03-14 | 2005-12-15 |  |  | 2003-03-14 | 2005-12-15 | 719d? | 272d | finish no earlier than 2005-12-15 | R3 | 5752h |  |  | Rel-7 | MIMO-IurIub |  | Howard Huang, Lucent | hchuang@lucent.com | TSG | Cesar |  |  |
| 10 | 5.4 | MIMO - RF Radio Transmission/Reception, System Performance Requirements and Conformance Testing |  | 524d? | 2003-12-12 A | 2005-12-15 | 5% | 497.8d? | 2003-12-12 | 2005-12-15 | 524d? | 272d | finish no earlier than 2005-12-15 | R4 | 4192h | 209.6h |  | Rel-7 | MIMO-RF |  | Man Hung Ng, Lucent | ngm@lucent.com | TSG | Cesar |  |  |
| 11 | 6 | **PS domain and IMS impacts for supporting IMS Emergency calls** |  | 1520d? | 2000-08-14 A | 2006-06-09 | 38% | 943.61d? | 2000-08-14 | 2005-12-08 | 1389d? | 145d |  | S2 | 60544h | 19151.3h |  | Rel-7 | EMC1 |  | Rainer Liebhart |  | TSG | Maurice |  |  |
| 12 | 10.1.1 | Service Requirements for IP-based emergency calls |  | 985d | 2000-09-18 A | 2004-06-25 A | 100% |  | 2000-09-18 | 2004-06-25 | 985d |  | finish no earlier than 2004-06-25 | S1 | 7880h | 7880h | 1314 | Rel-7 | EMC1 | 22.976 |  |  |  |  | CCaR |  |
| 13 | 6.2 | Study on Stage 2 for IMS-level solution |  | 668d? | 2003-02-26 A | 2005-09-16 | 90% | 66.8d? | 2003-02-26 | 2005-09-16 | 668d? | 335d | finish no earlier than 2005-09-16 | S2 | 5344h | 4809.6h |  | Rel-7 | EMC1 | 23.228, 23.060, 23.002 | Rainer Liebhart, Siemenws |  | TSG |  |  |  |
| 14 | 6.3 | Study on Stage 2 for GPRS-level solution |  | 301d? | 2004-10-14 A | 2005-12-08 | 80% | 60.2d? | 2004-10-14 | 2005-12-08 | 301d? | 276d | finish no earlier than 2005-12-08 | S2 | 2408h | 1926.4h |  | Rel-7 | EMC1 |  |  |  |  |  |  |  |
| 15 | 6.4 | Stage 2 Specification Phase - IMS-level |  | 200d? | 2005-09-05 | 2006-06-09 |  |  | 2004-10-14 | 2005-12-08 | 301d? | 145d | finish no earlier than 2006-06-09 | S2 | 1600h |  |  | Rel-7 | EMC1 |  |  |  |  |  |  |  |
| 16 | 6.5 | Stage 2 Specification Phase - GPRS-level |  | 200d? | 2005-09-05 | 2006-06-09 |  |  | 2004-10-14 | 2005-12-08 | 301d? | 145d | finish no earlier than 2006-06-09 | S2 | 1600h |  |  | Rel-7 | EMC1 |  |  |  |  |  |  |  |
| 17 | 10.1 | **Emergency Call Enhancements for IP& PS Based Calls – stage 3** |  | 1280.1d | 2000-08-14 A | 2005-07-11 |  | 1280.1d | 2000-08-14 | 2005-07-11 | 1280.1d | 384.9d |  | C1 | 29752h |  | 1653 | Rel-7 | EMC1 |  | Mr Atle Monrad, Ericsson | Atle.Monrad@eto.ericsson.se |  |  | CCaR |  |
| 18 | 10.1.2 | IMS aspects to support IMS Emergency sessions |  | 1209d | 2000-10-17 A | 2005-07-08 |  | 1209d | 2000-10-17 | 2005-07-08 | 1209d | 385.82d | finish no earlier than 2005-06-03 | C1 | 9672h |  | 1315 | Rel-7 | EMC1 | 24.229 | Mr Atle Monrad, Ericsson | Atle.Monrad@eto.ericsson.se |  |  | CCaR |  |
| 19 | 10.1.5 | PS domain aspects to support IMS Emergency sessions |  | 1255d | 2000-08-14 A | 2005-07-11 |  | 1255d | 2000-08-14 | 2005-07-11 | 1255d | 384.9d | finish no earlier than 2005-06-03 | C1 | 10040h |  | 1646 | Rel-7 | EMC1 | 24.008 | Mr Atle Monrad, Ericsson | Atle.Monrad@eto.ericsson.se |  |  | CCaR |  |
| 20 | 7 | **Access Class Barring and Overload Protection** |  | 440d? | 2004-03-15 A | 2005-11-18 | 38% | 270.77d? | 2004-03-15 | 2005-03-31 | 274d? | 290d |  | S2 | 9240h | 3553.84h |  | Rel-7 | ACBOP | 23.898 | Chris Pudney, Vodafone |  | TSG | Maurice |  |  |
| 21 | 7.1 | TR on Stage 2 |  | 274d? | 2004-03-15 A | 2005-03-31 A | 100% |  | 2004-03-15 | 2005-03-31 | 274d? |  | finish no earlier than 2005-03-31 | S2 | 2192h | 2192h |  | Rel-7 | ACBOP |  |  |  | TSG |  |  |  |
| 22 | 7.2 | Extra ACBOP information in GERAN |  | 440d? | 2004-03-15 | 2005-11-18 |  |  | 2004-03-15 | 2004-06-15 | 67d? | 290d | finish no earlier than 2005-11-18 | GP | 3520h |  |  | Rel-7 | ACBOP | 44.018 |  |  | TSG | Gert |  |  |
| 23 | 7.3 | Stage 3 CN aspects of ACBOP |  | 1d? | 2004-12-08 A | 2004-12-08 A | 100% |  | 2004-12-08 | 2004-12-08 | 1d? |  | finish no earlier than 2004-12-08 | C1 | 8h | 8h |  | Rel-7 | ACBOP |  |  |  |  |  |  |  |
| 24 | 7.4 | Deleted - Potential impact on Iu interface Overload functionality | milestone | 0d? | 2004-03-15 A | 2004-03-15 A | 100% |  | 2004-03-15 | 2004-03-15 | 0d? |  | finish no earlier than 2004-03-15 | RP |  |  |  | Rel-7 | ACBOP | 25.413 |  |  |  |  |  | RP-25 |
| 25 | 7.5 | Deleted - Extra ACBOP information in RAN | milestone | 0d? | 2004-03-15 A | 2004-03-15 A | 100% |  | 2004-03-15 | 2004-03-15 | 0d? |  | finish no earlier than 2004-03-15 | RP |  |  |  | Rel-7 | ACBOP | 25.331 |  |  |  |  |  | RP-25 |

Notes:
- 23: NEW - inserted on 2/9/2004

| ID | WBS | Task | Duration | Start | Finish | Complete | Remaining | Baseline start | Baseline finish | Baseline duration | Total slack | Constraint | Resources | Work | Actual work | Text1 | Text3 | Text6 | Text7 | Text8 | Text4 | Text5 |
| --- | --- | --- | --- | --- | --- | --- | --- | --- | --- | --- | --- | --- | --- | --- | --- | --- | --- | --- | --- | --- | --- | --- |
| 26 | 8 | **USSD message delivery and transfer to USIM** | 443.7d? | 2004-03-05 A | 2005-11-16 | 29% | 313.06d? | 2004-03-05 | 2005-11-16 | 443.7d? | 292.3d |  | S1 | 6781.6h | 1996.71h | USSD-USIM | 22.090 | Rel-7 | TSG | Michael |  |  |
| 27 | 8.1 | Stage 1 | 152d? | 2004-03-18 A | 2004-10-15 | 80% | 30.4d? | 2004-03-18 | 2004-10-15 | 152d? | 575d | start no earlier than 2004-03-18 | S1 | 1216h | 972.8h | USSD-USIM | 22.090 | Rel-7 | TSG | Michael |  |  |
| 28 | 8.2 | Alignment with requirements regarding USSD usage | 261d? | 2004-03-05 A | 2005-11-16 |  | 261d? | 2004-03-05 | 2005-11-16 | 261d? | 292.3d | finish no earlier than 2005-03-04 | C6 | 2088h |  | USSD-USIM |  | Rel-7 | TSG |  | Christophe Dubois (Axalto) | cdubois@axalto.com |
| 29 | 9 | **Location Services enhancements Rel-7** | 513d? | 2004-06-28 A | 2006-06-15 | 40% | 309.34d? | 2004-06-28 | 2006-06-15 | 513d? | 142d |  | S2 | 23349.6h | 8148.62h | LCS3 | 23.271 | Rel-7 |  | Maurice |  |  |
| 30 | 9.1 | Global Stage 2 for LCS3 | 321d? | 2004-12-31 A | 2006-03-24 | 55% | 144.45d? | 2004-12-31 | 2006-03-24 | 321d? | 200d | finish no earlier than 2006-03-24 | S2 | 2568h | 1412.4h | LCS3 | 23.271 | Rel-7 | TSG | Maurice | Ben Rodilitz, SiRF | brodilitz@sirf.com |
| 31 | 9.2 | **LCS for 3GPP Interworking WLAN** | 329d? | 2004-06-28 A | 2005-09-29 | 65% | 115.15d? | 2004-06-28 | 2005-09-29 | 329d? | 326d |  | S1 | 5165.6h | 1745.24h | LCS3-IWLAN | 22.935 | Rel-7 | TSG | Michael | Mike Loushine, (Telcordia) |  |
| 32 | 9.2.1 | FS on 3GPP system to WLAN Interworking with LCS | 316.7d? | 2004-06-28 A | 2005-09-29 | 65% | 110.84d? | 2004-06-28 | 2005-09-29 | 316.7d? | 326d | finish no earlier than 2005-09-29 | S1 | 2533.6h | 1646.84h | LCS3-IWLAN | 22.935 | Rel-7 |  |  |  |  |
| 33 | 9.3 | **UE positioning Rel-7** | 456d? | 2004-09-15 A | 2006-06-15 | 35% | 296.78d? | 2004-09-15 | 2006-06-15 | 456d? | 142d |  | RP | 8872h | 3097.73h | LCS3-UEpos |  | Rel-7 | TSG | Cesar |  |  |
| 34 | 9.3.1 | Inclusion of Uplink TDOA UE positioning method in the UTRAN specifications | 456d? | 2004-09-15 A | 2006-06-15 | 50% | 228d? | 2004-09-15 | 2006-06-15 | 456d? | 142d | finish no earlier than 2006-06-15 | R2 | 3648h | 1824h | LCS3-UEPos-UTDOA | TS25.305, TS25.453 | Rel-7 | TSG | Cesar | Robert Gross, TruePosition | rlgross@trueposition.com |
| 35 | 9.3.2 | NEW!! LCS Enhancements Related to Location-Based Services | 197d? | 2005-03-15 | 2005-12-15 |  |  | 2005-03-15 | 2005-12-15 | 197d? | 272d | finish no earlier than 2005-12-15 | R2 | 1576h |  | LCS3-UEPos-Velocity | 25.305, 25.331, 25.410, 25.413, 25.453 | Rel-7 | TSG | Cesar | Ben Rodilitz | BRodilitz@SiRF.com |
| 36 | 9.4 | LCS Enhancements Related to Location-Based Services | 330d? | 2005-01-03 A | 2006-04-07 | 10% | 297d? | 2005-01-28 | 2005-11-11 | 206d? | 190d |  | GP | 2640h | 264h | LCS3-LBS | 43.059, 44.031, 48.008, 49.031 | Rel-7 | TSG | Paolo | Kevin Judge, SiRF Technologies | kjudge@sirf.com |
| 37 | 10 | **Selective Disabling of UE Capabilities** | 489.36d? | 2005-01-24 A | 2006-12-08 | 45% | 271.46d? | 2005-01-24 | 2006-12-08 | 489.36d? | 15d |  | S1 | 8308.8h | 3699.74h | SDoUE | 22.xxx | Rel-7 | TSG | Michael | Nigel Barnes (Motorola Ltd) | Nigel.Barnes@motorola.com |
| 38 | 10.1 | Stage 1 | 393.6d? | 2005-01-24 A | 2006-12-08 | 22% | 307.01d? | 2005-01-24 | 2006-12-08 | 393.6d? | 15d | finish no earlier than 2006-12-08 | S1 | 3148.8h | 692.74h | SDoUE-CRs | 22.101 | Rel-7 | TSG | Michael | Nigel Barnes (Motorola Ltd) | Nigel.Barnes@motorola.com |
| 39 | 10.2 | TR on different possible architectures | 195d? | 2005-03-21 A | 2005-12-16 | 90% | 19.5d? | 2005-03-21 | 2005-12-16 | 195d? | 270d | finish no earlier than 2005-12-16 | S2 | 1560h | 1404h | SDoUE | 23.805 | Rel-7 |  | Maurice |  |  |
| 40 | 11 | **Combinational Services** | 205d? | 2005-01-17 A | 2005-10-28 | 51% | 100.13d? | 2005-01-17 | 2005-10-28 | 205d? | 305d |  | S1 | 5696h | 2913.72h | CSICS |  | Rel-7 | TSG | Michael | Robert Frank, TeliaSonera | Robert.Frank@teliasonera.com |
| 41 | 11.1 | Stage 1 for CSICS | 104d? | 2005-01-17 A | 2005-06-09 | 85% | 15.6d? | 2005-01-17 | 2005-06-09 | 104d? | 406d | start no earlier than 2005-01-17 | S1 | 832h | 707.2h | CSICS | 22.279 | Rel-7 | TSG |  |  |  |
| 42 | 11.2 | Stage 2 for CSICS | 130d? | 2005-01-17 A | 2005-07-15 | 95% | 6.5d? | 2005-01-17 | 2005-07-15 | 130d? | 380d | start no earlier than 2005-01-17 | S2 | 1040h | 988h | CSICS | 23.279 | Rel-7 |  |  |  |  |
| 43 | 11.3 | Stage 3 for CSICS CN aspects | 130d? | 2005-05-02 A | 2005-10-28 | 20% | 104d? | 2005-05-02 | 2005-10-28 | 130d? | 305d | start no earlier than 2005-05-01 | C1 | 1040h | 208h | CSICS | 24.229, 24.008 | Rel-7 | TSG | Andrijana | Peter Dawes (Vodafone) |  |
| 44 | 11.4 | Stage 3 for codec aspects | 143d? | 2005-03-15 A | 2005-09-29 | 15% | 121.55d? | 2005-03-15 | 2005-09-29 | 143d? | 326d | finish no earlier than 2005-09-29 | S4 | 1144h | 171.6h | CSICS-Codec | TS 26.141, 26.235, 26.236 | Rel-7 | TSG | Paolo | Per Fröjdh, Ericsson | Per.Frojdh@ericsson.com |
| 45 | 12 | **All-IP Network (AIPN)** | 448d? | 2004-06-28 A | 2006-03-15 | 47% | 236.68d? | 2004-06-28 | 2006-03-15 | 448d? | 207d |  | S1 | 8672h | 4090.57h | AIPN | 22.978 | Rel-7 | TSG | Michael | Chris Sachno (NTT DoCoMo) | c.masyu@nttdocomo.co.jp |
| 46 | 12.1 | All-IP Network Feasibility Study | 188d? | 2004-06-28 A | 2005-03-16 A | 100% |  | 2004-06-28 | 2005-03-16 | 188d? |  | start no earlier than 2004-06-28 | S1 | 1504h | 1504h | AIPFS | 22.978 | Rel-7 | TSG | Michael | Chris Sachno (NTT DoCoMo) | c.masyu@nttdocomo.co.jp |
| 47 | 12.2 | Stage1 | 448d? | 2004-06-28 A | 2006-03-15 | 25% | 336d? | 2004-06-28 | 2006-03-15 | 448d? | 207d | finish no earlier than 2006-03-15 | S1 | 3584h | 896h | AIPN | 22.258 | Rel-7 | TSG | Michael | Chris Sachno (NTT DoCoMo) | c.masyu@nttdocomo.co.jp |
| 48 | 13 | Enhancement of E2E QoS | 336.4d? | 2004-06-28 A | 2005-12-01 A | 100% |  | 2004-06-28 | 2005-12-01 | 336.4d? |  | finish no earlier than 2005-12-01 | S2 | 2691.2h | 2691.2h | QoS7 | 23.802 | Rel-7 | TSG | Maurice |  |  |
| 49 | 14 | **System enhancements for fixed broadband access to IMS** | 353d? | 2004-08-03 A | 2005-12-08 | 50% | 175.87d? | 2004-08-03 | 2005-12-08 | 353d? | 276d |  | S2 | 7401.6h | 3714.04h | FBI |  | Rel-7 | TSG | Maurice |  |  |
| 50 | 14.1 | Stage 2 | 301d? | 2004-10-14 A | 2005-12-08 | 47% | 159.53d? | 2004-10-14 | 2005-09-07 | 235d? | 276d | finish no earlier than 2005-12-08 | S2 | 2408h | 1131.76h | FBI |  | Rel-7 | TSG | Maurice |  |  |
| 51 | 14.2 | Protocol impact from providing IMS services via fixed broadband | 347d? | 2004-08-03 A | 2005-11-30 | 70% | 104.1d? | 2004-08-03 | 2005-11-30 | 347d? | 282d | finish no earlier than 2005-03-03 | C1 | 2776h | 1943.2h | FBI | new TR, 24.229, 29.229, 29.163, 29.209 | Rel-7 | TSG | Andrijana | Siemens |  |
| 52 | 14.3 | Security Enhancements for Fixed Broadband Access to IMS | 118d? | 2005-06-28 | 2005-12-08 |  |  | 2005-06-28 | 2005-12-08 | 118d? | 276d | start no earlier than 2005-06-28 | S3 | 944h |  | ISE | 33.102, 43.020 | Rel-7 |  | Mike | Bengt Sahlin, Ericsson | Bengt.Sahlin@ericsson.com |
| 53 | 15 | Access Security Enhancements | 195d? | 2005-01-03 A | 2005-09-30 | 30% | 136.5d? |  |  |  | 325d | finish no earlier than 2005-09-30 | S3 | 1560h | 468h | ACCSEC2 | 33.102, 43.020 | Rel-7 | TSG | Michael | Bengt Sahlin, Ericsson | Bengt.Sahlin@ericsson.com |
| 54 | 16 | Mp (MRFC - MRFP) interface | 644d | 2002-12-13 | 2005-06-01 |  |  | 2002-12-13 | 2005-06-01 | 644d | 412d | finish no earlier than 2005-06-01 | C4 | 5152h |  | IMSLocal |  | Rel-7 |  |  |  |  |
| 55 | 17 | IMS Stage 3 IETF Protocol alignment | 261d? | 2004-12-10 A | 2005-12-09 | 20% | 208.8d? | 2004-12-10 | 2005-12-09 | 261d? | 275d | finish no earlier than 2005-12-09 | C1 | 2088h | 417.6h | IMSProtoc |  | Rel-7 |  |  |  |  |

Notes:
- 30: Approved SA#27. Appropriate place forEmergency work to be found
- 32: DAB - Should be SA1
- 34: Approved at RP#25 as RP-040387
- 36: Linked SP-040682
- 44: Started
- 48: DAB - pushed back to June
- 51: WI sent to NP#25 for approval
- 52: Duplicated entry ("ACCSEC2", "Access Security Enhancements", SP-040865) deleted by A.Sultan
- 53: WID approved SA#26. Record created after SA#27. It is about improved GERAN security
- 54: 27/11/2002 KK: WID approved at CN#18 (NP-020601)........

| ID | WBS | Task | Type | Duration | Start | Finish | Complete | Remaining | Baseline start | Baseline finish | Baseline duration | Total slack | Constraint | Resources | Work | Actual work | Text1 | Text6 | Text8 | Text4 | Text5 | Text7 |
| --- | --- | --- | --- | --- | --- | --- | --- | --- | --- | --- | --- | --- | --- | --- | --- | --- | --- | --- | --- | --- | --- | --- |
| 56 | 18 | **Rel-7 Improvements of the Radio Interface** |  | 390d? | 2004-09-15 A | 2006-03-15 | 39% | 239.41d? | 2004-09-15 | 2006-03-15 | 390d? | 208d |  | RP | 13032h | 5031.89h | RInImp | Rel-7 | Cesar |  |  |  |
| 57 | 18.1 | UMTS 2.6 GHz |  | 195d? | 2004-09-15 A | 2005-06-14 A | 100% |  | 2004-09-15 | 2005-06-14 | 195d? |  | finish no earlier than 2005-06-14 | R4 | 1560h | 1560h | RInImp-UMTS2600 | Rel-7 | Cesar | Jussi Numminen, Nokia | jussi.numminen@nokia.com | TSG |
| 58 | 18.2 | UMTS 2.6 GHz TDD |  | 261d? | 2004-12-15 A | 2005-12-15 | 35% | 169.65d? | 2004-12-15 | 2005-12-15 | 261d? | 272d | finish no earlier than 2005-12-15 | R4 | 2088h | 730.8h | RInImp-UMTS2600TDD | Rel-7 | Cesar | Shin Horng Wong (IPWireless) | shwong@IPWIRELESS.COM | TSG |
| 59 | 18.3 | UMTS 900 MHz |  | 261d? | 2004-12-15 A | 2005-12-15 | 30% | 182.7d? | 2004-12-15 | 2005-12-15 | 261d? | 272d | finish no earlier than 2005-12-15 | R4 | 2088h | 626.4h | RInImp-UMTS900 | Rel-7 | Cesar | Yannick Li (Nortel) | yli@nortelnetworks.com | TSG |
| 60 | 18.4 | NEW!! UMTS 1700 MHz |  | 197d? | 2005-03-15 | 2005-12-15 |  |  | 2005-03-15 | 2005-12-15 | 197d? | 272d | finish no earlier than 2005-12-15 | R4 | 1576h |  | RInImp-UMTS1700 | Rel-7 | Cesar | Takehiro Nakamura | NTT DoCoMo | TSG |
| 61 | 18.5 | UE Antenna Performance Evaluation Method and Requirements |  | 325d? | 2004-12-15 A | 2006-03-15 | 35% | 211.25d? | 2004-12-15 | 2006-03-15 | 325d? | 208d | finish no earlier than 2006-03-15 | R4 | 2600h | 910h | RInImp-UEAnt | Rel-7 | Cesar | Christian Bergljung (TeliaSonera) | Christian.Bergljung@TeliaSonera.com | TSG |
| 62 | 18.6 | NEW!! Improved Performance Requirements for HSDPA UE based on Rx Diversity (type 1) & LMMSE equalizer (type 2) | milestone | 0d? | 2005-03-15 | 2005-03-15 |  |  | 2005-03-15 | 2005-03-15 | 0d? | 469d | finish no earlier than 2005-03-15 | R4 |  |  | RInImp-HSPerf-Type3 | Rel-7 | Cesar | Marc Grant | marc.grant@cingular.com | TSG |
| 63 | 19 | **7.68Mcps TDD option** |  | 456d? | 2004-09-15 A | 2006-06-15 | 20% | 363.97d? | 2004-09-15 | 2006-06-15 | 456d? | 142d |  | RP | 17728h | 3577.83h | VHCRTDD | Rel-7 | Cesar | Martin Beale, IPWireless | mbeale@ipwireless.com | TSG |
| 64 | 19.1 | VHCRTDD: Stage 2 |  | 326d? | 2004-09-15 A | 2005-12-15 | 15% | 277.1d? | 2004-09-15 | 2005-12-15 | 326d? | 272d | finish no earlier than 2005-12-15 | R1 | 2608h | 391.2h | VHCRTDD-Stage2 | Rel-7 | Cesar | Martin Beale, IPWireless | mbeale@ipwireless.com | TSG |
| 65 | 19.2 | VHCRTDD: Physical Layer |  | 326d? | 2004-09-15 A | 2005-12-15 | 15% | 277.1d? | 2004-09-15 | 2005-12-15 | 326d? | 272d | finish no earlier than 2005-12-15 | R1 | 2608h | 391.2h | VHCRTDD-Phys | Rel-7 | Cesar | Martin Beale, IPWireless | mbeale@ipwireless.com | TSG |
| 66 | 19.3 | VHCRTDD: Layer 2 and layer 3 protocol aspects |  | 326d? | 2004-09-15 A | 2005-12-15 | 15% | 277.1d? | 2004-09-15 | 2005-12-15 | 326d? | 272d | finish no earlier than 2005-12-15 | R2 | 2608h | 391.2h | VHCRTDD-L23 | Rel-7 | Cesar | Derek Richards, IPWireless | drichards@ipwireless.com | TSG |
| 67 | 19.4 | VHCRTDD: UTRAN Iub/Iur Protocol Aspects |  | 326d? | 2004-09-15 A | 2005-12-15 | 15% | 277.1d? | 2004-09-15 | 2005-12-15 | 326d? | 272d | finish no earlier than 2005-12-15 | R3 | 2608h | 391.2h | VHCRTDD-IurIub | Rel-7 | Cesar | Peter Legg, IPWireless | plegg@ipwireless.com | TSG |
| 68 | 19.5 | VHCRTDD: RF Radio Transmission/ Reception, System Performance Requirements and Conformance Testing |  | 456d? | 2004-09-15 A | 2006-06-15 | 35% | 296.4d? | 2004-09-15 | 2006-06-15 | 456d? | 142d | finish no earlier than 2006-06-15 | R4 | 3648h | 1276.8h | VHCRTDD-RF | Rel-7 | Cesar | Shin Horng Wong | shwong@ipwireless.com | TSG |
| 69 | 20 | **Rel-7 RAN improvements** |  | 325d? | 2004-12-15 A | 2006-03-15 | 19% | 263.13d? | 2004-12-15 | 2006-03-15 | 325d? | 208d |  | RP | 8336h | 1586.98h | RANimp | Rel-7 | Cesar |  |  | TSG |
| 70 | 20.1 | Optimisation of channelisation code utilisation for 1.28 Mcps TDD |  | 195d? | 2004-12-15 A | 2005-09-14 | 70% | 58.5d? | 2004-12-15 | 2005-09-14 | 195d? | 338d | finish no earlier than 2005-09-14 | R1 | 1560h | 1092h | RANimp-RABSE-CodOptLCRTDD | Rel-7 | Cesar | Ka Leong Lo | kaleong.lo@utstar.com | TSG |
| 71 | 20.2 | Delay optimisation for procedures applicable to CS and PS Connections |  | 261d? | 2005-03-15 | 2006-03-15 |  |  | 2005-03-15 | 2006-03-15 | 261d? | 208d | finish no earlier than 2006-03-15 | R2 | 2088h |  | RANimp-DelayOpt | Rel-7 | Cesar | Juho Pirskanen | juho.pirskanen@nokia.com | TSG |
| 72 | 20.3 | UE Performance Requirements for MBMS (TDD) |  | 261d? | 2005-03-15 | 2006-03-15 |  |  | 2005-03-15 | 2006-03-15 | 261d? | 208d | finish no earlier than 2006-03-15 | R4 | 2088h |  | MBMS-RAN-RF-TDD | Rel-7 | Cesar | Shin Horng Wong | shwong@ipwireless.com | TSG |
| 73 | 21 | **3.84 Mcps TDD Enhanced Uplink** |  | 327d? | 2005-03-15 A | 2006-06-15 | 7% | 302.48d? | 2005-03-15 | 2006-06-15 | 327d? | 142d |  | RP | 13072h | 980.15h | EDCHTDD | Rel-7 | Cesar | Nicholas Anderson | nanderson@ipwireless.com | TSG |
| 74 | 21.1 | EDCHTDD: Stage 2 |  | 197d? | 2005-03-15 A | 2005-12-14 | 10% | 177.3d? | 2005-03-15 | 2005-12-14 | 197d? | 272d | start no earlier than 2005-03-15 | R2 | 1576h | 157.6h | EDCHTDD-Stage2 | Rel-7 | Cesar | Nicholas Anderson | nanderson@ipwireless.com | TSG |
| 75 | 21.2 | EDCHTDD: Physical Layer |  | 261d? | 2005-03-15 A | 2006-03-14 | 10% | 234.9d? | 2005-03-15 | 2006-03-14 | 261d? | 208d | start no earlier than 2005-03-15 | R1 | 2088h | 208.8h | EDCHTDD-Phys | Rel-7 | Cesar | Nicholas Anderson | nanderson@ipwireless.com | TSG |
| 76 | 21.3 | EDCHTDD: Layer 2 and 3 Protocol Aspects |  | 261d? | 2005-03-15 A | 2006-03-14 | 15% | 221.85d? | 2005-03-15 | 2006-03-14 | 261d? | 208d | start no earlier than 2005-03-15 | R2 | 2088h | 313.2h | EDCHTDD-L23 | Rel-7 | Cesar | Derek Richards | drichards@ipwireless.com | TSG |
| 77 | 21.4 | EDCHTDD: UTRAN Iub/Iur Protocol Aspects |  | 261d? | 2005-03-15 A | 2006-03-14 | 5% | 247.95d? | 2005-03-15 | 2006-03-14 | 261d? | 208d | start no earlier than 2005-03-15 | R3 | 2088h | 104.4h | EDCHTDD-IurIub | Rel-7 | Cesar | Jim Miller | jim.miller@interdigital.com | TSG |
| 78 | 21.5 | EDCHTDD: RF Radio Transmission/ Reception, System Performance Requirements and Conformance Testing |  | 327d? | 2005-03-15 | 2006-06-15 |  |  | 2005-03-15 | 2006-06-15 | 327d? | 142d | finish no earlier than 2006-06-15 | R4 | 2616h |  | EDCHTDD-RF | Rel-7 | Cesar | Shin Horng Wong | shwong@ipwireless.com | TSG |
| 79 | 22 | **Support of SMS and MMS over generic 3GPP IP access** |  | 432d? | 2004-10-14 A | 2006-06-09 | 40% | 260.59d? | 2004-10-14 | 2005-06-13 | 173d? | 145d |  | S2 | 6944h | 2560.4h | SMSIP | Rel-7 |  |  |  | TSG |
| 80 | 22.1 | FS on SMSIP |  | 173d? | 2004-10-14 A | 2005-06-13 A | 100% |  | 2004-10-14 | 2005-06-13 | 173d? |  | start no earlier than 2004-10-14 | S2 | 1384h | 1384h | SMSIP | Rel-7 |  |  |  |  |
| 81 | 22.2 | Stage 2 for SMSIP |  | 263d? | 2005-06-08 | 2006-06-09 |  |  | 2005-06-07 | 2005-06-07 | 0d? | 145d | start no earlier than 2005-06-08 | S2 | 2104h |  | SMSIP | Rel-7 |  |  |  |  |

Notes:
- 57: Approved at RP#25 as RP-040377 / Text3: TS25.101, TS25.104, TS25.133, TS25.141, TS25.331, TS25.942, TS25.306, TS25.307, TS34.121
- 58: Text3: 25.102, 25.105, 25.113, 25.123, 25.142, 25.331, 25.942, 25.306, 25.307, 34.122, 34.124
- 59: Text3: 25.101, 25.104, 25.113, 25.133, 25.141, 25.331, 25.942, 25.306, 25.307, 34.121
- 60: Text3: 25.101, 25.104, 25.113, 25.133, 25.141, 25.306, 25.307, 25.331, 34.121
- 61: Text3: TS25.101
- 62: Text3: 25.101
- 63: Approved at RP#25 as RP-040365
- 64: Approved at RP#25 as RP-040365 / Text3: New specification
- 65: Approved at RP#25 as RP-040365 / Text3: TS25.221, TS25.222, TS25.223, TS25.224,TS25.225
- 66: Approved at RP#25 as RP-040365 / Text3: TS25.301, TS25.302, TS25.305, TS25.306, TS25.321, TS25.331
- 67: Approved at RP#25 as RP-040365 / Text3: TS25.401, TS25.420, TS25.423, TS25.425, TS25.427, TS25.430, TS25.433, TS25.435
- 68: Approved at RP#25 as RP-040365 / Text3: TS25.102, TS25.105, TS25.123, TS25.133, TS25.142
- 69: Generic feature
- 71: Text3: TS25.321, TS25.322, TS25.331
- 72: Text3: TS25.102, TS25.123
- 75: Text3: TS25.201, TS25.221,TS25.222, TS25.223, TS25.224, TS25.225
- 76: Text3: TS25.301, TS25.302, TS25.306, TS25.321, TS25.331
- 77: Text3: TS25.401, TS25.420, TS25.423, TS25.427, TS25.430, TS25.433, TS25.435
- 78: Text3: TS25.102, TS25.105, TS25.123, TS25.142
- 79: DAB - pushed back to June

| ID | WBS | Task | Type | Duration | Start | Finish | Complete | Remaining | Baseline start | Baseline finish | Baseline duration | Total slack | Constraint | Resources | Work | Actual work | Text1 | Text6 | Text7 | Text8 | Text4 | Text5 |
| --- | --- | --- | --- | --- | --- | --- | --- | --- | --- | --- | --- | --- | --- | --- | --- | --- | --- | --- | --- | --- | --- | --- |
| 82 | 23 | **Evolution of Policy Control and Charging** |  | 437d? | 2004-10-14 A | 2006-06-16 | 65% | 154.69d? | 2004-10-14 | 2005-12-28 | 315d? | 140d |  | S2 | 8016h | 4180h | PCC | Rel-7 | TSG | Maurice |  |  |
| 83 | 23.1 | TR for PCC |  | 315d? | 2004-10-14 A | 2005-12-29 A | 100% |  |  |  |  |  | finish no earlier than 2005-12-28 | S2 | 2520h | 2520h | PCC | Rel-7 |  |  |  |  |
| 84 | 23.2 | Stage 2 for PCC |  | 250d? | 2005-07-04 A | 2006-06-16 | 20% | 200d? |  |  |  | 140d | start no earlier than 2005-07-04 | S2 | 2000h | 400h | PCC | Rel-7 |  |  |  |  |
| 85 | 24 | **Advanced Global Navigation Satellite System (A-GNSS) concept** |  | 470d? | 2004-06-28 A | 2006-04-14 | 17% | 388.12d? | 2004-06-28 | 2005-09-29 | 329d? | 185d |  | S1 | 9649.6h | 1176.4h | LCS3-AGNSS | Rel-7 | TSG | Michael | Michel MONNERAT | Michel.monnerat@space.alcatel.fr |
| 86 | 24.1 | Support for GNSS in GERAN |  | 451.2d? | 2004-06-28 | 2006-04-14 |  |  | 2004-06-28 | 2005-09-02 | 291.2d? | 185d | finish no earlier than 2006-04-14 | GP | 3609.6h |  | AGNSS-GP | Rel-7 | TSG | Paolo | Richard Couty, ALCATEL SA | richard.couty@space.alcatel.fr |
| 87 | 24.2 | Towards A-GNSS Concept |  | 285d? | 2004-08-27 A | 2005-09-29 | 45% | 156.75d? | 2004-08-27 | 2005-09-29 | 285d? | 326d | finish no earlier than 2005-09-29 | S1 | 2280h | 1026h | GNSS | Rel-7 | TSG | Paolo | Richard Couty, ALCATEL SA | richard.couty@space.alcatel.fr |
| 88 | 25 | Video Codec Performance Requirements |  | 314d? | 2005-01-03 A | 2006-03-16 | 25% | 235.5d? | 2005-01-03 | 2006-03-16 | 314d? | 206d | finish no earlier than 2006-03-16 | S4 | 2512h | 628h | VICPer | Rel-7 | TSG | Paolo | Juergen Pandel (Siemens AG) | juergen.pandel@siemens.com |
| 89 | 26 | DIAMETER on the GGSN Gi interface |  | 266d? | 2004-09-10 | 2005-09-16 |  |  | 2004-09-10 | 2005-09-16 | 266d? | 335d | finish no earlier than 2005-09-16 | C3 | 2128h |  | DIAMGi | Rel-7 | TSG | Seung Don | Stefan Koppenborg (T-Mobile) | stefan.koppenborg@t-mobile.de |
| 90 | 27 | **CAMEL Trunk Triggers** |  | 251d? | 2004-12-17 A | 2005-12-05 | 53% | 119.22d? | 2004-12-17 | 2005-12-05 | 251d? | 279.5d |  | S1 | 6024h | 3162.6h | TTCAMEL | Rel-7 | TSG | Michael | Amar Deol, Nortel Networks | deola@nortelnetworks.com |
| 91 | 27.1 | Stage 1 for CAMEL Trunk Triggers |  | 251d? | 2004-12-17 A | 2005-12-05 | 95% | 12.55d? | 2004-12-17 | 2005-12-05 | 251d? | 279.5d |  | S1 | 2008h | 1907.6h | TTCAMEL | Rel-7 | TSG | Michael | Amar Deol, Nortel Networks | deola@nortelnetworks.com |
| 92 | 27.2 | CAMEL Trunk Originated Trigger Detection Points |  | 251d? | 2004-12-17 A | 2005-12-05 | 10% | 225.9d? | 2004-12-17 | 2005-12-05 | 251d? | 279.5d | start no earlier than 2004-12-17 | C4 | 2008h | 200.8h | CamelR7 | Rel-7 | TSG | Kimmo | David Hutton, Nortel Networks | dhutton@nortel.com |
| 93 | 28 | MS Antenna Performance Evaluation Method and Requirements |  | 206d? | 2005-01-28 A | 2005-11-11 | 10% | 185.4d? | 2005-01-28 | 2005-11-11 | 206d? | 295d | finish no earlier than 2005-11-11 | G1 | 1648h | 164.8h | APEMR | Rel-7 | TSG | Paolo | Ulf.Tegth (TeliaSonera) | Ulf.Tegth@teliasonera.com |
| 94 | 29 | **Lower 700 MHz Inclusion in the GERAN Specifications** |  | 345d? | 2005-01-03 A | 2006-04-28 | 43% | 197.39d? | 2005-01-28 | 2005-06-24 | 106d? | 175d |  | GP | 6552h | 1625.6h | GSM710 | Rel-7 | TSG | Paolo | Dave Cotton (UTC) | dcotton@mtview.union-tel.com |
| 95 | 29.1 | Inclusion of the 698 – 746 MHz band into GERAN core specifications |  | 129d? | 2005-01-03 A | 2005-06-30 A | 100% |  |  |  |  |  | finish no earlier than 2005-06-30 | G1 | 1032h | 1032h | GSM710-core | Rel-7 |  | Paolo |  |  |
| 96 | 29.2 | Inclusion of the 698 – 746 MHz band into GERAN test specifications |  | 172.5d? | 2005-08-31 | 2006-04-28 |  |  |  |  |  | 175d | finish no earlier than 2006-04-28 | G3; G1; | 2760h |  | GSM-710-test | Rel-7 |  | Stoyan |  |  |
| 97 | 30 | **Enhancements of VGCS for public authority officials** |  | 333d? | 2004-08-27 A | 2005-12-06 | 43% | 189.95d? | 2004-08-27 | 2004-08-27 | 0d? | 278d |  | C1 | 7856h | 3374.81h | EGCS | Rel-7 | TSG | Andrijana | Siemens |  |
| 98 | 30.1 | Stage 1 | milestone | 0d? | 2004-08-27 A | 2004-08-27 A | 100% |  | 2004-08-27 | 2004-08-27 | 0d? |  | finish no earlier than 2004-08-27 | S1 |  |  | EGCS | Rel-7 | TSG | Michael | Joerg Swetina (Siemens AG) | joerg.swetina@SIEMENS.COM |
| 99 | 30.2 | Architecture and protocol aspects |  | 333d? | 2004-08-27 A | 2005-12-06 | 60% | 133.2d? |  |  |  | 278d | start no earlier than 2004-08-27 | C1 | 2664h | 1598.4h | EVGCS | Rel-7 |  |  |  |  |
| 100 | 30.3 | GERAN2 aspects |  | 316d? | 2004-08-27 A | 2005-11-11 | 25% | 237d? | 2004-08-27 | 2004-08-27 | 0d? | 295d | finish no earlier than 2005-11-11 | G2 | 2528h | 632h | EVGCS | Rel-7 | TSG | Gert | Ken Isaacs (Siemens) | kenneth.isaacs@roke.co.uk |
| 101 | 31 | **Improvements of VGCS for parallel use of services** |  | 380d? | 2004-06-28 A | 2005-12-09 | 15% | 321.42d? | 2004-06-28 | 2005-10-11 | 337d? | 275d |  | C1 | 10208h | 1573.7h | IVGCS | Rel-7 |  |  |  |  |
| 102 | 31.1 | Deleted - Enhancements of VGCS |  | 337d? | 2004-06-28 A | 2005-10-11 | 19% | 273.77d? | 2004-06-28 | 2005-10-11 | 337d? | 318d |  | S1 | 2696.02h | 505.85h | EGCS | Rel-7 | TSG | Michael | Joerg Swetina (Siemens AG) | joerg.swetina@SIEMENS.COM |
| 103 | 31.2 | Deleted- Stage 1 |  | 161d? | 2005-03-01 | 2005-10-11 |  |  | 2005-03-01 | 2005-10-11 | 161d? | 318d | start no earlier than 2005-03-01 | S1 | 1288h |  | IVGCS | Rel-7 | TSG | Michael | Kurt Bischinger (T-Mobile) | kurt.bischinger@t-mobile.at |
| 104 | 31.3 | Service Requirements for VGCS improvements |  | 62d? | 2005-03-15 | 2005-06-08 |  |  | 2005-03-15 | 2005-06-08 | 62d? | 407d | finish no earlier than 2005-06-08 | S1 | 496h |  | IVGCS | Rel-7 | TSG | Michael | Kurt Bischinger (T-Mobile) | kurt.bischinger@t-mobile.at |
| 105 | 31.4 | Stage 2 modifications for VGCS improvements |  | 142d? | 2005-03-15 | 2005-09-28 |  |  | 2005-03-15 | 2005-09-28 | 142d? | 327d | finish no earlier than 2005-09-28 | C1 | 1136h |  | IVGCS | Rel-7 | TSG |  | Kurt Bischinger (T-Mobile) | kurt.bischinger@t-mobile.at |
| 106 | 31.5 | Architecture and protocol aspects |  | 194d? | 2005-03-15 A | 2005-12-09 | 39% | 119.1d? |  |  |  | 275d | finish no earlier than 2005-12-09 | C1 | 1552h | 599.2h | IVGCS | Rel-7 |  |  |  |  |

Notes:
- 86: Not started
- 88: Text3: 26.234, 26.235, 26.346, 26.140
- 89: Not started
- 92: Not started
- 93: Started / Text3: 25.9xx, 45.005
- 94: Started / Text3: 24.008, 43.022, 44.018, 44.118, 45, 001, 45.005, 51.010, 51.021
- 95: Completed / Text3: 24.008, 43.022, 44.018, 44.118, 45, 001, 45.005,
- 96: Not started / Text3: 51.010, 51.021
- 97: Text3: 43.068, 44.068, 24.008, 29.002
- 98: Text3: 42.068, 43.068
- 102: covered by Rel6's UID 11045 / Text3: 42.068, 43.068
- 103: covered by UID 31070 / Text3: 42.068
- 104: Text3: 42.068
- 105: Text3: 42.068

| ID | WBS | Task | Type | Duration | Start | Finish | Complete | Remaining | Baseline start | Baseline finish | Baseline duration | Total slack | Constraint | Resources | Work | Actual work | Text1 | Text4 | Text5 | Text6 | Text7 | Text8 | Text3 | Text10 |
| --- | --- | --- | --- | --- | --- | --- | --- | --- | --- | --- | --- | --- | --- | --- | --- | --- | --- | --- | --- | --- | --- | --- | --- | --- |
| 107 | 32 | **OSA Rel-7** |  | 142d? | 2005-03-15 A | 2005-09-28 | 20% | 113.95d? | 2005-03-15 | 2005-09-28 | 142d? | 327d |  | S1 | 2768h | 546.82h | OSA7-SB | Eamonn Murray (AePONA) | eamonn.murray@aepona.com | Rel-7 | TSG | Michael |  |  |
| 108 | 32.1 | Service Requirements for OSA Service Broker |  | 62d? | 2005-03-15 A | 2005-06-08 | 65% | 21.7d? | 2005-03-15 | 2005-06-08 | 62d? | 407d | finish no earlier than 2005-06-08 | S1 | 496h | 322.4h | OSA7-SB | Eamonn Murray (AePONA) | eamonn.murray@aepona.com | Rel-7 | TSG | Michael | 22.127 |  |
| 109 | 32.2 | Stage 2 modifications for OSA Service Broker |  | 142d? | 2005-03-15 | 2005-09-28 |  |  | 2005-03-15 | 2005-09-28 | 142d? | 327d | finish no earlier than 2005-09-28 | CT5 | 1136h |  | OSA7-SB | Eamonn Murray (AePONA) | eamonn.murray@aepona.com | Rel-7 | TSG | Adrian | 23.198 |  |
| 110 | 33 | Dynamic and interactive multimedia scenes |  | 194d? | 2005-03-15 A | 2005-12-09 | 15% | 164.9d? | 2005-03-15 | 2005-12-09 | 194d? | 275d | finish no earlier than 2005-12-09 | S4 | 1552h | 232.8h | DIMS | Gaëlle MARTIN-COCHER (Streamezzo) | gaelle.martin-cocher@streamezzo.com | Rel-7 | TSG | Paolo | 26.234, 23.346, 26.140, 26.244 |  |
| 111 | 34 | Liberty Alliance and 3GPP Security Interworking |  | 147d? | 2005-03-10 A | 2005-09-30 | 10% | 132.3d? | 2005-03-10 | 2005-09-30 | 147d? | 325d | finish no earlier than 2005-09-30 | S3 | 1176h | 117.6h | LibSec | Silke Holtmanns, Nokia | Silke.Holtmanns@NOKIA.COM | Rel-7 | TSG | Maurice |  |  |
| 112 | 35 | **WLAN-UMTS Interworking Phase 2** |  | 371d? | 2004-01-05 A | 2005-06-07 | 99% | 0d? | 2004-01-05 | 2005-06-07 | 371d? | 409d |  | S1 | 3888h | 3888h |  | Fredric Paint, Telenor | frederic.paint@telenor.com | Rel-7 | TSG | Michael |  |  |
| 113 | 35.1 | Stage 1 on Session Continuity |  | 115d? | 2004-01-05 A | 2004-06-11 A | 100% |  | 2004-01-05 | 2004-06-11 | 115d? |  | start no earlier than 2004-01-05 | S1 | 920h | 920h | WLAN-SC |  |  | Rel-7 |  |  |  | SP-24 |
| 114 | 35.2 | Stage 2 on Session Continuity: covered by SAE | milestone | 0d? | 2005-06-07 | 2005-06-07 |  |  | 2005-06-07 | 2005-06-07 | 0d? | 409d | finish no earlier than 2005-06-07 | S2 |  |  |  |  |  | Rel-7 |  |  |  |  |
| 115 | 36 | **Voice call continuity between CS and IMS (incl. I-WLAN)** |  | 376d? | 2004-12-31 A | 2006-06-09 | 39% | 230.77d? | 2005-03-14 | 2005-12-24 | 205d? | 145d |  | S2 | 6560h | 2142.4h | VCC | Andy Bennett, Lucent; Roger Bunting, Cingular | andybennett@lucent.com | Rel-7 |  | Maurice | 22.101, 22.228, 23.228 |  |
| 116 | 36.1 | TR for VCC |  | 245d? | 2004-12-31 A | 2005-12-08 | 70% | 73.5d? |  |  |  | 276d | finish no earlier than 2005-12-08 | S2 | 1960h | 1372h | VCC |  |  | Rel-7 |  |  |  |  |
| 117 | 36.2 | Stage 2 for VCC |  | 199d? | 2005-09-06 | 2006-06-09 |  |  |  |  |  | 145d | finish no earlier than 2006-06-09 | S2 | 1592h |  | VCC |  |  | Rel-7 |  |  |  |  |
| 118 | 37 | DIAMETER on the PDG Wi inteface |  | 266d? | 2004-09-10 | 2005-09-16 |  |  | 2004-09-10 | 2005-09-16 | 266d? | 335d | finish no earlier than 2005-09-16 | C3 | 2128h |  | DIAMWi | Stefan Koppenborg (T-Mobile) | stefan.koppenborg@t-mobile.de | Rel-7 | TSG | Seung Don |  |  |
| 119 | 38 | **OAM&P** |  | 750d? | 2004-02-16 A | 2006-12-29 | 1% | 744.1d? | 2004-02-16 | 2006-12-29 | 750d? | 0d |  | S5 | 42897.1h | 4100.43h | OAM7 | Michael TRUSS (Motorola) | Michael.Truss@MOTOROLA.COM | Rel-7 | TSG | Adrian | 32-series |  |
| 120 | 38.1 | **Network Infrastructure Management** |  | 341d? | 2005-09-02 | 2006-12-22 |  |  | 2005-09-02 | 2006-12-22 | 341d? | 5d |  | S5 | 16400h |  | OAM7-NIM | Michael TRUSS (Motorola) | Michael.Truss@MOTOROLA.COM | Rel-7 |  |  |  |  |
| 121 | 38.1.1 | Enhance NRM to accommodate NGN (IMS as basis of the Next Generation Network) |  | 341d? | 2005-09-02 | 2006-12-22 |  |  | 2005-09-02 | 2006-12-22 | 341d? | 5d | finish no earlier than 2006-12-22 | S5 | 2728h |  | OAM7-NIM-NGN | BT |  | Rel-7 |  |  |  |  |
| 122 | 38.1.2 | IRP usage scenarios |  | 69d? | 2005-09-02 | 2005-12-07 |  |  | 2005-09-02 | 2005-12-07 | 69d? | 277d | finish no earlier than 2005-12-07 | S5 | 552h |  | OAM7-NIM | Lucent |  | Rel-7 |  |  |  |  |
| 123 | 38.1.3 | Co-operative Element Management interface (CO-OP) |  | 151d? | 2005-09-02 | 2006-03-31 |  |  | 2005-09-02 | 2006-03-31 | 151d? | 195d | finish no earlier than 2006-03-31 | S5 | 1208h |  | OAM7-NIM-COOP | Motorola |  | Rel-7 |  |  |  |  |
| 124 | 38.1.4 | Network Management (NM) Itf-N performance criteria |  | 69d? | 2005-09-02 | 2005-12-07 |  |  | 2005-09-02 | 2005-12-07 | 69d? | 277d | finish no earlier than 2005-12-07 | S5 | 552h |  | OAM7-NIM | China Mobile |  | Rel-7 |  |  |  |  |
| 125 | 38.1.5 | Delta synchronization between IRP Manager and IRP Agent |  | 69d? | 2005-09-02 | 2005-12-07 |  |  | 2005-09-02 | 2005-12-07 | 69d? | 277d | finish no earlier than 2005-12-07 | S5 | 552h |  | OAM7-NIM | Siemens |  | Rel-7 |  |  |  |  |
| 126 | 38.1.6 | Subscription Management (SuM) IRP Solution Sets |  | 151d? | 2005-09-02 | 2006-03-31 |  |  | 2005-09-02 | 2006-03-31 | 151d? | 195d | finish no earlier than 2006-03-31 | S5 | 1208h |  | OAM7-NIM-SuM | T-Mobile |  | Rel-7 |  |  |  |  |
| 127 | 38.1.7 | Integration Reference Point (IRP) Security Management |  | 216d? | 2005-09-02 | 2006-06-30 |  |  | 2005-09-02 | 2006-06-30 | 216d? | 130d | finish no earlier than 2006-06-30 | S5 | 1728h |  | OAM7-NIM | Huawei |  | Rel-7 |  |  |  |  |
| 128 | 38.1.8 | Integration Reference Point (IRP) Methodology |  | 69d? | 2005-09-02 | 2005-12-07 |  |  | 2005-09-02 | 2005-12-07 | 69d? | 277d | finish no earlier than 2005-12-07 | S5 | 552h |  | OAM7-NIM | Ericsson |  | Rel-7 |  |  |  |  |
| 129 | 38.1.9 | Partial suspension of Itf-N during maintenance/testing |  | 69d? | 2005-09-02 | 2005-12-07 |  |  | 2005-09-02 | 2005-12-07 | 69d? | 277d | finish no earlier than 2005-12-07 | S5 | 552h |  | OAM7-NIM | Siemens |  | Rel-7 |  |  |  |  |
| 130 | 38.1.10 | Advanced Alarming on Itf-N |  | 216d? | 2005-09-02 | 2006-06-30 |  |  | 2005-09-02 | 2006-06-30 | 216d? | 130d | finish no earlier than 2006-06-30 | S5 | 1728h |  | OAM7-NIM | Siemens |  | Rel-7 |  |  |  |  |
| 131 | 38.1.11 | Management of Legacy Equipment |  | 69d? | 2005-09-02 | 2005-12-07 |  |  | 2005-09-02 | 2005-12-07 | 69d? | 277d | finish no earlier than 2005-12-07 | S5 | 552h |  | OAM7-NIM | Siemens |  | Rel-7 |  |  |  |  |
| 132 | 38.1.12 | Rules for Vendor Specific Extensions |  | 151d? | 2005-09-02 | 2006-03-31 |  |  | 2005-09-02 | 2006-03-31 | 151d? | 195d | finish no earlier than 2006-03-31 | S5 | 1208h |  | OAM7-NIM | Siemens |  | Rel-7 |  |  |  |  |
| 133 | 38.1.13 | CN CS Bearer Transport Network (BTN) relative NRM |  | 69d? | 2005-09-02 | 2005-12-07 |  |  | 2005-09-02 | 2005-12-07 | 69d? | 277d | finish no earlier than 2005-12-07 | S5 | 552h |  | OAM7-NIM | China Mobile |  | Rel-7 |  |  |  |  |

Notes:
- 110: Started
- 111: WID approved SA#27.
- 112: Created at TSG#27 by A. Sultan because of WLAN items belonging to Rel-7
- 115: WID approved SA#27. Revised at SA#28.
- 118: Not started
- 119: Created at TSG#27 by A. Sultan due to the split of the OAM BB Trace Rel-6/Rel-7
- 120: SA#28 (06/2005) created
- 121: SA#28 (06/2005) created
- 122: SA#28 (06/2005) created
- 123: SA#28 (06/2005) created
- 124: SA#28 (06/2005) created
- 125: SA#28 (06/2005) created
- 126: SA#28 (06/2005) created
- 127: SA#28 (06/2005) created
- 128: SA#28 (06/2005) created
- 129: SA#28 (06/2005) created
- 130: SA#28 (06/2005) created
- 131: SA#28 (06/2005) created
- 132: SA#28 (06/2005) created
- 133: SA#28 (06/2005) created

| ID | WBS | Task | Duration | Start | Finish | Complete | Remaining | Baseline start | Baseline finish | Baseline duration | Total slack | Constraint | Resources | Work | Actual work | Text1 | Text4 | Text5 | Text6 | Text7 | Text8 |
| --- | --- | --- | --- | --- | --- | --- | --- | --- | --- | --- | --- | --- | --- | --- | --- | --- | --- | --- | --- | --- | --- |
| 134 | 38.2 | **Performance Management** | 346d? | 2005-09-02 | 2006-12-29 |  |  | 2005-09-02 | 2006-12-29 | 346d? | 0d |  | S5 | 8400h |  | OAM7-PM | Christian TOCHE (Nortel) | toche@NORTEL.COM | Rel-7 |  |  |
| 135 | 38.2.1 | Performance measurements definition for CN CS | 151d? | 2005-09-02 | 2006-03-31 |  |  | 2005-09-02 | 2006-03-31 | 151d? | 195d | finish no earlier than 2006-03-31 | S5 | 1208h |  | OAM7-PM | China Mobile |  | Rel-7 |  |  |
| 136 | 38.2.2 | Enhancement UTRAN performance measurements definition | 69d? | 2005-09-02 | 2005-12-07 |  |  | 2005-09-02 | 2005-12-07 | 69d? | 277d | finish no earlier than 2005-12-07 | S5 | 552h |  | OAM7-PM | China Mobile |  | Rel-7 |  |  |
| 137 | 38.2.3 | Add TDD specific counters in Performance measurement | 346d? | 2005-09-02 | 2006-12-29 |  |  | 2005-09-02 | 2006-12-29 | 346d? | 0d | finish no earlier than 2006-12-29 | S5 | 2768h |  | OAM7-PM | CATT |  | Rel-7 |  |  |
| 138 | 38.2.4 | ATM bearer network Performance measurements | 69d? | 2005-09-02 | 2005-12-07 |  |  | 2005-09-02 | 2005-12-07 | 69d? | 277d | finish no earlier than 2005-12-07 | S5 | 552h |  | OAM7-PM | ZTE |  | Rel-7 |  |  |
| 139 | 38.2.5 | IP bearer network Performance measurement definitions | 69d? | 2005-09-02 | 2005-12-07 |  |  | 2005-09-02 | 2005-12-07 | 69d? | 277d | finish no earlier than 2005-12-07 | S5 | 552h |  | OAM7-PM | China Mobile |  | Rel-7 |  |  |
| 140 | 44.5 | **Trace Management** | 620d? | 2004-02-16 A | 2006-06-30 | 3% | 604.19d? | 2004-02-16 | 2005-12-08 | 474d? | 130d |  | S5 | 12097.1h | 308.43h | OAM7-Trace | Christian TOCHE | toche@NORTEL.COM | Rel-7 | TSG |  |
| 141 | 38.3.1 | Trace Management for IMS | 154d? | 2005-05-09 A | 2005-12-08 | 5% | 146.3d? | 2005-05-09 | 2005-12-08 | 154d? | 276d | finish no earlier than 2005-12-08 | S5 | 1232h | 61.6h | OAM7-Trace-IMS | Nortel |  | Rel-7 | TSG |  |
| 142 | 38.3.2 | SIP enhancements for trace | 603.14d? | 2004-02-16 A | 2006-06-16 | 2% | 591.08d? | 2004-02-16 | 2005-06-17 | 343d? | 140d | finish no earlier than 2006-06-16 | C1 | 4825.12h | 96.5h | Trace-SIP |  |  | Rel-7 |  |  |
| 143 | 38.3.3 | End-to-end Service Level tracing for IMS | 166d? | 2005-11-11 | 2006-06-30 |  |  | 2005-05-09 | 2005-12-08 | 154d? | 130d | start no earlier than 2005-11-11 | S5 | 1328h |  | OAM7-Trace-IMS | Vodafone | David.Sanders@Vodafone.com | Rel-7 | TSG |  |
| 144 | 38.3.4 | Trace record content for UTRAN TDD | 154d? | 2005-05-09 A | 2005-12-08 | 5% | 146.3d? | 2005-05-09 | 2005-12-08 | 154d? | 276d | finish no earlier than 2005-12-08 | S5 | 1232h | 61.6h | OAM7-Trace | CATT | wangxuelong@datangmobile.cn | Rel-7 | TSG |  |
| 145 | 39 | **TBC: Generic User Profile Phase 2** | 820.4d | 2002-01-01 A | 2005-02-22 |  | 820.4d | 2002-01-01 | 2005-02-22 | 820.4d | 483.6d |  | C4 | 9376h |  |  |  |  | Rel-7 |  | Gaby |
| 146 | 30.4 | Stage 3 - Common objects | 586d | 2002-01-01 A | 2005-02-22 |  | 586d | 2002-01-01 | 2005-02-22 | 586d | 483.6d | finish no earlier than 2005-03-03 | C4 | 4688h |  |  |  |  | Rel-7 | TSG | Gaby |
| 147 | 40 | Trust Requirements for Open Platforms in 3GPP | 115d? | 2005-01-03 A | 2005-06-10 | 10% | 103.5d? | 2005-01-03 | 2005-06-10 | 115d? | 405d | finish no earlier than 2005-06-10 | S3 | 920h | 92h | TrustOP | Selim Aissi, Sundeep Bajikar, Intel Corporation | selim.aissi@intel.com; sundeep.bajikar@intel.com | Rel-7 | TSG | Michael |
| 148 | 41 | Development of UEA2 and UIA2 | 268d? | 2004-12-01 A | 2005-12-09 | 50% | 134d? | 2004-12-01 | 2005-12-09 | 268d? | 275d | finish no earlier than 2005-12-09 | S3 | 2144h | 1072h | AlgUEA2 | Per Christoffersson, Teliasonera | per.christoffersson@teliasonera.com | Rel-7 | TSG | Michael |
| 149 | 42 | Lawful Interception in the 3GPP Rel-7 architecture | 118d? | 2005-06-28 | 2005-12-08 |  |  | 2005-06-28 | 2005-12-08 | 118d? | 276d | start no earlier than 2005-06-28 | S3 | 944h |  | LI-7A | Berthold Wilhelm, BMWI | berthold.wilhelm@regtp.de | Rel-7 |  | Mike |
| 150 | 43 | **Support of Conversational Services in A/Gb mode via the PS domain** | 276d? | 2005-04-08 A | 2006-04-28 |  | 276d? | 2005-04-08 | 2006-04-28 | 276d? | 175d |  | GP | 8611.2h | 198.72h | SCSAGB | Gunnar Hedby, Ericsson | gunnar.hedby@ericsson.com | Rel-7 |  | Paolo |
| 151 | 43.1 | Definition of radio resource management functionality | 276d? | 2005-04-08 | 2006-04-28 |  |  | 2005-04-08 | 2006-04-28 | 276d? | 175d | finish no earlier than 2006-04-28 | G1 | 2208h |  | SCSAGB-RRM | Gunnar Hedby, Ericsson | gunnar.hedby@ericsson.com | Rel-7 |  | Paolo |
| 152 | 43.2 | Radio Channel Support | 276d? | 2005-04-08 | 2006-04-28 |  |  | 2005-04-08 | 2006-04-28 | 276d? | 175d | finish no earlier than 2006-04-28 | G2 | 2208h |  | SCSAGB-RCHS | Gunnar Hedby, Ericsson | gunnar.hedby@ericsson.com | Rel-7 |  | Gert |
| 153 | 43.3 | Modifications to FLO | 276d? | 2005-04-08 | 2006-04-28 |  |  | 2005-04-08 | 2006-04-28 | 276d? | 175d | finish no earlier than 2006-04-28 | G2 | 2208h |  | SCSAGB-FLO | Gunnar Hedby, Ericsson | gunnar.hedby@ericsson.com | Rel-7 |  | Gert |
| 154 | 44 | **Addition of new frequency band to GSM (T-GSM810)** | 161d? | 2005-04-08 A | 2005-11-18 | 28% | 115.25d? | 2005-04-08 | 2005-09-02 | 106d? | 290d |  | GP | 4272h | 848h | T-GSM810 | Chen De, Huawei | chende@huawei.com | Rel-7 |  | Paolo |
| 155 | 44.1 | Changes to core specification | 106d? | 2005-04-08 A | 2005-09-02 A | 100% |  | 2005-04-08 | 2005-06-24 | 56d? |  | finish no earlier than 2005-09-02 | GP | 848h | 848h | T-GSM810-Core | Chen De, Huawei | chende@huawei.com | Rel-7 |  | Paolo |
| 156 | 44.2 | Changes to MS testing specification | 161d? | 2005-04-08 | 2005-11-18 |  |  | 2005-04-08 | 2005-09-02 | 106d? | 290d | finish no earlier than 2005-11-18 | G3 | 1288h |  | T-GSM810-Mstest | Chen De, Huawei | chende@huawei.com | Rel-7 |  | Stoyan |
| 157 | 44.3 | Changes to BTS testing specification | 106d? | 2005-04-08 | 2005-09-02 |  |  | 2005-04-08 | 2005-09-02 | 106d? | 345d | finish no earlier than 2005-09-02 | G1 | 848h |  | T-GSM810-BTStest | Chen De, Huawei | chende@huawei.com | Rel-7 |  | Paolo |

Notes:
- 134: SA#28 (06/2005) created
- 137: SA#28 (06/2005) created
- 138: SA#28 (06/2005) created
- 139: SA#28 (06/2005) created
- 140: TSG#27: SA5 BB WID to add Trace for IMS (SIP) CN1 24.229 has IETF dependency
- 141: Text3: 32.421,32.422,32.423
- 143: 07/2005: OMA (Stage 1), Stage 2/3 SA5, CT1/3/4 / Text3: 32.101,32.421,32.422,32.423
- 144: Text3: 32.421,32.422,32.423
- 145: Created at TSG#27 by A. Sultan because of the move to Rel-7 of "Common Objects".
- 146: No progress in CN4#26. This have to be moved to Rel-7. It was deleted from WID / Text3: 24.241
- 147: WID approved SA#26. Record created after SA#27
- 148: WID approved SA#26, Dependant on Funding Availability. Record created after SA#27 / Text3: 33.102
- 150: Originally started Nov. 2003 as GP-030443
- 151: Not started (PS HO must be completed first)
- 152: Not started (PS HO must be completed first)
- 153: Not started (PS HO must be completed first)
- 154: Text3: 45.005, 45.050, 24.008, 45.008, 45.001, 43.022, 43.030, 44.018, 44.060, 51.010-1, 51.021
- 155: Text3: 45.005, 45.050, 24.008, 45.008, 45.001, 43.022, 43.030, 44.018, 44.060
- 156: Text3: 51010-1
- 157: Text3: 51021

| ID | WBS | Task | Duration | Start | Finish | Complete | Remaining | Baseline start | Baseline finish | Baseline duration | Total slack | Constraint | Resources | Work | Actual work | Text1 | Text4 | Text5 | Text6 | Text8 | Text3 | Text7 |
| --- | --- | --- | --- | --- | --- | --- | --- | --- | --- | --- | --- | --- | --- | --- | --- | --- | --- | --- | --- | --- | --- | --- |
| 158 | 45 | **Handover of dedicated and shared resources while in dual transfer mode** | 421d? | 2005-04-08 A | 2006-11-17 | 6% | 395.99d? | 2005-04-08 | 2006-11-17 | 421d? | 30d |  | GP | 8944h | 331.2h | HO-DSRDTM | Rami Vaittinen, Nokia | rami.vaittinen@nokia.com | Rel-7 | Paolo |  |  |
| 159 | 45.1 | Handover of dedicated and shared resources while in dual transfer mode | 276d? | 2005-04-08 A | 2006-04-28 | 15% | 234.6d? | 2005-04-08 | 2006-11-17 | 421d? | 175d | finish no earlier than 2006-04-28 | G2 | 2208h | 331.2h | HO-DSRDTM | Rami Vaittinen, Nokia | rami.vaittinen@nokia.com | Rel-7 | Gert | 43.055, 44.018, 44.060 |  |
| 160 | 45.2 | BTS conformance testing | 421d? | 2005-04-08 | 2006-11-17 |  |  | 2005-04-08 | 2006-11-17 | 421d? | 30d | finish no earlier than 2006-11-17 | G1 | 3368h |  | HO-DSRDTM-BTStest | Rami Vaittinen, Nokia | rami.vaittinen@nokia.com | Rel-7 | Paolo | 51.026 |  |
| 161 | 46 | Future GERAN Evolution | 156d? | 2005-04-08 A | 2005-11-11 | 60% | 62.4d? | 2005-04-08 | 2005-11-11 | 156d? | 295d | finish no earlier than 2005-11-11 | GP | 1248h | 748.8h | FGE | Eddie Riddington, Nokia Corporation | eddie.riddington@nokia.com | Rel-7 | Paolo |  |  |
| 162 | 47 | 3G-324M Video Telephony Call Setup Times Improvements | 391d? | 2005-06-08 | 2006-12-06 |  |  | 2005-06-08 | 2006-12-06 | 391d? | 17d | finish no earlier than 2006-12-06 | S4 | 3128h |  | VTCSTI | Edward Hall (Vodafone) | edward.hall@vodafone.co.uk | Rel-7 | Paolo | 26.abc |  |
| 163 | 48 | Personal Network (PN) and Personal Area Network (PAN) | 101.2d? | 2005-07-11 | 2005-12-08 |  |  | 2005-07-11 | 2005-12-08 | 101.2d? | 276d | finish no earlier than 2005-12-08 | S1 | 809.6h |  | PNPAN | Armin Toepfer, Vodafone | armin.toepfer@vodafone.com | Rel-7 | Mike |  |  |
| 164 | 49 | Multimedia Telephony Capabilities for IMS | 101.2d? | 2005-07-11 | 2005-12-08 |  |  | 2005-07-11 | 2005-12-08 | 101.2d? | 276d | finish no earlier than 2005-12-08 | S1 | 809.6h |  | MITE | Peter Bleckert, Ericsson | peter.bleckert @ericsson.com | Rel-7 | Mike |  |  |
| 165 | 50 | Transferring of emergency Call data | 109d? | 2005-07-11 | 2005-12-08 |  |  | 2005-07-11 | 2005-12-08 | 109d? | 276d | finish no earlier than 2005-12-08 | S1 | 872h |  | eCALL | Steve Vardy, (Motorola S.A.S) | steven.vardy@motorola.com | Rel-7 | Mike |  |  |
| 166 | 51 | MBMS Enhancements | 109d? | 2005-07-11 | 2005-12-08 |  |  | 2005-07-11 | 2005-12-08 | 109d? | 276d | finish no earlier than 2005-12-08 | S1 | 872h |  | MBMSE | Liu Hong, China Mobile | liuhongyfw@chinamobile.com | Rel-7 | Mike |  |  |
| 167 | 52 | **Identification of Communication Services in IMS** | 355d? | 2005-05-02 A | 2006-09-08 | 30% | 249.71d? | 2005-05-02 | 2006-07-24 | 321d? | 80d |  | S2 | 5656h | 963.2h | ServID | Stephen Terrill, Ericsson | stephen.terrill@ericsson.com | Rel-7 | Maurice | 23.228, 23.218, 23.125 |  |
| 168 | 52.1 | TR for ICS | 232d? | 2005-05-02 A | 2006-03-21 | 45% | 127.6d? |  |  |  | 203d | finish no earlier than 2006-03-20 | S2 | 1856h | 835.2h | ServID |  |  | Rel-7 |  |  |  |
| 169 | 52.2 | Stage 2 for ICS | 120d? | 2006-03-27 | 2006-09-08 |  |  |  |  |  | 80d | finish no earlier than 2006-09-08 | S2 | 960h |  | ServID |  |  | Rel-7 |  |  |  |
| 170 | 53 | **VoIMS bearer related enhancements** | 354d? | 2005-03-15 A | 2006-07-21 | 16% | 298.26d? |  |  |  | 115d |  | S2 | 8959.2h | 981.2h | VoIMS |  |  | Rel-7 |  |  |  |
| 171 | 53.1 | FS on enhancement of radio performance for VoIMS | 320d? | 2005-05-02 A | 2006-07-21 | 25% | 240d? | 2005-05-02 | 2006-07-24 | 321d? | 115d | finish no earlier than 2006-07-21 | S2 | 2560h | 640h | VoIMS | Laurence Lautier, Nortel Networks | lautierl@nortel.com | Rel-7 | Maurice |  |  |
| 172 | 53.2 | Improved support of IMS Realtime Services using HSDPA/HSUPA | 197d? | 2005-03-15 A | 2005-12-14 | 15% | 167.45d? | 2005-03-15 | 2005-12-14 | 197d? | 272d | start no earlier than 2005-03-15 | R2 | 1576h | 236.4h | RInImp-IMSRealTime | Don Zelmer | don.zelmer@CINGULAR.COM | Rel-7 | Cesar |  | TSG |
| 173 | 53.3 | Performance Characterization of VoIMS over HSDPA\EUL channels20028 | 262d? | 2005-03-15 A | 2006-03-15 | 5% | 248.9d? | 2005-03-15 | 2006-03-15 | 262d? | 207d | finish no earlier than 2006-03-15 | S4 | 2096h | 104.8h | PCVoIMS | Dimitris Vasilaras (Lucent Technologies) | dvasilaras@lucent.com | Rel-7 | Paolo | 26.935 | TSG |
| 174 | 54 | Rel-7 Feasibility Studies listed below | 1d? | 2000-01-03 | 2000-01-03 |  |  | 2000-01-03 | 2000-01-03 | 1d? | 1824d |  |  |  |  |  |  |  | Rel-7 |  |  |  |
| 175 | 55 | Behaviour of Multi system UEs | 188d? | 2004-06-28 A | 2005-03-16 | 60% | 75.2d? | 2004-06-28 | 2005-03-16 | 188d? | 467d | start no earlier than 2004-06-28 | S1 | 1504h | 902.4h | BMSU | D Williams (QUALCOMM) | dwilliams@qualcomm.com | Rel-7 | Michael | 22.936 | TSG |
| 176 | 56 | **FS on IMS with real time services deployment** | 384d? | 2004-06-28 A | 2005-12-15 | 78% | 82.57d? | 2004-06-28 | 2005-12-15 | 384d? | 271d |  | S1 | 10680h | 6676.24h | IRTSD |  |  | Rel-7 | Maurice |  | TSG |
| 177 | 56.1 | Feasibility Study on Combining CS calls and IMS sessions | 384d? | 2004-06-28 A | 2005-12-15 A | 100% |  | 2004-06-28 | 2005-12-15 | 384d? |  | start no earlier than 2004-06-28 | S1 | 3072h | 3072h | IRTSD-CS_IMS |  |  | Rel-7 | Michael | 22.979, 23.899 | TSG |
| 178 | 56.2 | TR on Stage 2 (IMS services using CS bearers) | 316d? | 2004-06-28 A | 2005-09-12 | 75% | 79d? | 2004-06-28 | 2005-09-12 | 316d? | 339d | finish no earlier than 2005-09-12 | S2 | 2528h | 1896h | IRTSD-IMSCS | Mark Watson (Nortel Networks) |  | Rel-7 | Maurice | 23.899 | TSG |
| 179 | 56.3 | Deleted - TS on Stage 2 (IMS services using CS bearers) | 251d? | 2004-06-28 A | 2005-06-13 | 50% | 125.5d? | 2004-06-28 | 2005-06-13 | 251d? | 404d | finish no earlier than 2005-06-13 | S2 | 2008h | 1004h | IRTSD-IMSCS | Mark Watson (Nortel Networks) |  | Rel-7 | Maurice |  | TSG |
| 180 | 57 | **3GPP System Architecture Evolution** | 401d? | 2004-12-03 A | 2006-06-16 | 8% | 367.12d? | 2004-12-03 | 2006-06-16 | 401d? | 140d |  | S2 | 8104h | 684.6h | SAE |  |  | Rel-7 |  |  | TSG |
| 181 | 57.1 | Stage 2 description of Interim conclusion | 211d? | 2004-12-03 A | 2005-09-23 | 15% | 179.35d? | 2004-12-03 | 2005-09-23 | 211d? | 330d | finish no earlier than 2005-09-23 | S2 | 1688h | 253.2h | SAE |  |  | Rel-7 |  | 23.8xx |  |
| 182 | 57.2 | Stage 2 Feasibility study on 3GPP architectural development | 401d? | 2004-12-03 A | 2006-06-16 | 5% | 380.95d? | 2004-12-03 | 2006-06-16 | 401d? | 140d | finish no earlier than 2006-06-16 | S2 | 3208h | 160.4h | SAE |  |  | Rel-7 |  | 23.8xx |  |
| 183 | 58 | FS on Performance Evaluation of the UE behaviour in high speed trains with speeds up to 350 kmph | 261d? | 2005-03-15 A | 2006-03-14 | 5% | 247.95d? | 2005-03-15 | 2006-03-14 | 261d? | 208d | start no earlier than 2005-03-15 | R4 | 2088h | 104.4h | RANFS-HSTrains | Mike Vogel | Mike.vogel@vodafone.com | Rel-7 | Cesar |  | TSG |
| 184 | 59 | FS of enhanced support of Video Telephony | 316d? | 2004-08-27 A | 2005-11-11 | 35% | 205.4d? | 2004-08-27 | 2005-09-02 | 266d? | 295d | finish no earlier than 2005-11-11 | GP | 2528h | 884.8h | VIDGER | Stefan Eriksson, Ericsson | stefan.g.eriksson@ericsson.com | Rel-7 | Paolo |  | TSG |
| 185 | 60 | FS on Evolved UTRA and UTRAN | 130d? | 2004-12-15 A | 2005-06-15 | 20% | 104d? | 2004-12-15 | 2005-06-15 | 130d? | 403d | finish no earlier than 2005-06-15 | RP | 1040h | 208h | RANFS-Evo | Takehiro Nakamura (NTT DoCoMo) | nakamurata@NTTDOCOMO.CO.JP | Rel-7 | Cesar |  | TSG |

Notes:
- 158: Started at GERAN#24
- 159: Started at GERAN#24
- 160: Not started
- 161: FS started
- 162: Conditionally, in the event Phase 2 is needed, end is Dec.06
- 167: WID approved SA#28
- 170: Created by MCC to group all VoIMS related items, after consultation of chairs
- 171: WID approved SA#28
- 173: Started
- 175: This is a feature in its own right.
- 179: covered by 32084
- 184: FS started
- 185: vice rapporteur Don Zelmar (Cingular)

| ID | WBS | Task | Type | Duration | Start | Finish | Complete | Remaining | Baseline start | Baseline finish | Baseline duration | Total slack | Constraint | Resources | Work | Actual work | Text1 | Text4 | Text5 | Text6 | Text7 | Text8 | Text3 |
| --- | --- | --- | --- | --- | --- | --- | --- | --- | --- | --- | --- | --- | --- | --- | --- | --- | --- | --- | --- | --- | --- | --- | --- |
| 186 | 61 | **Study on Videotelephony teleservice** |  | 452d? | 2005-03-15 A | 2006-12-06 | 30% | 316.4d? | 2005-03-15 | 2006-12-06 | 452d? | 17d |  | S1 | 7232h | 2169.6h | VidTel | Kurt Bischinger (T-Mobile) | kurt.bischinger@t-mobile.at | Rel-7 | TSG | Michael |  |
| 187 | 61.1 | Study on Videotelephony service requirements |  | 452d? | 2005-03-15 A | 2006-12-06 | 30% | 316.4d? | 2005-03-15 | 2006-12-06 | 452d? | 17d | finish no earlier than 2006-12-06 | S1 | 3616h | 1084.8h | VidTel | Kurt Bischinger (T-Mobile) | kurt.bischinger@t-mobile.at | Rel-7 | TSG | Michael | 22.101 |
| 188 | 62 | **Study of Network Selection Principles** |  | 193d? | 2005-03-15 A | 2005-12-08 | 33% | 129.31d? | 2005-03-15 | 2005-12-08 | 193d? | 276d |  | S1 | 3088h | 1623.54h | NetSel | Chris Friel (O2) | chris.friel@o2.com | Rel-7 | TSG | Michael |  |
| 189 | 62.1 | Review of Network Selection Principles |  | 193d? | 2005-03-15 A | 2005-12-08 | 33% | 129.31d? | 2005-03-15 | 2005-12-08 | 193d? | 276d | finish no earlier than 2005-12-08 | S1 | 1544h | 509.52h | NetSel | Chris Friel (O2) | chris.friel@o2.com | Rel-7 | TSG | Michael | 22.811 |
| 190 | 63 | FS on Enhancements to support QoS provisioning over 3GPP/WLAN Interworking |  | 391d? | 2005-03-14 A | 2006-09-11 | 25% | 293.25d? | 2005-03-14 | 2006-09-12 | 392d? | 79d | finish no earlier than 2006-09-11 | S2 | 3128h | 782h | WLAN-SC | Osok Song, Samsung | osok.song@samsung.com | Rel-7 |  | Maurice |  |
| 191 | 64 | FS on Continuous connectivity for packet data users |  | 132d? | 2005-03-15 | 2005-09-15 |  |  | 2005-03-15 | 2005-09-15 | 132d? | 337d | finish no earlier than 2005-09-15 | R1 | 1056h |  | RANFS-cont-packet | Joerg Gustrau | joerg.gustrau@siemens.com | Rel-7 | TSG | Cesar |  |
| 192 | 65 | FS on UTRA Tower Mounted Amplifier (FDD) |  | 195d? | 2005-06-15 | 2006-03-15 |  |  | 2005-06-15 | 2006-03-15 | 195d? | 208d | finish no earlier than 2006-03-15 | R4 | 1560h |  | RANFS-TMA | Klas Sjerling | Klas.Sjerling@ericsson.com | Rel-7 | TSG | Cesar |  |
| 193 | 66 | Multimedia Priority Service |  | 450d? | 2003-03-28 A | 2004-12-16 | 60% | 180d? | 2003-03-28 | 2004-12-16 | 450d? | 531d | finish no earlier than 2004-12-16 | S1 | 3600h | 2160h |  |  |  | Rel-6 |  | Michael | 22.953 |
| 194 | 67 | **Deleted: FS on applicability of GALILEO for LCS** |  | 484d? | 2003-08-25 A | 2005-06-30 |  | 484d? | 2003-08-25 | 2005-06-30 | 484d? | 391d |  | S2 | 3872h | 1000h | Galileo |  |  | Rel-7 |  |  |  |
| 195 | 67.1 | Deleted - TR on Stage 2 | milestone | 0d? | 2005-06-30 A | 2005-06-30 A | 100% |  | 2005-06-30 | 2005-06-30 | 0d? |  | finish no earlier than 2005-06-30 | S2 |  |  | Galileo |  |  | Rel-7 |  |  |  |
| 196 | 67.2 | deleted - GERAN review of the TR | milestone | 0d? | 2003-08-25 | 2003-08-25 |  |  | 2003-08-25 | 2003-08-25 | 0d? | 875d | finish no earlier than 2003-08-25 | GP |  |  | Galileo |  |  | Rel-7 |  |  |  |
| 197 | 16.7 | **Deleted - IMS Local services** |  | 1158d? | 2001-01-01 A | 2005-06-08 | 68% | 367.35d? | 2001-01-01 | 2005-06-08 | 1158d? | 407d |  | S2 | 13072h | 5192.02h | IMSLocal |  |  | Rel-7 |  |  | 23.228 |
| 198 | 16.7.1 | Deleted - Stage 2 |  | 325d | 2001-01-01 A | 2002-03-29 A | 100% |  | 2001-01-01 | 2002-03-29 | 325d |  | start no earlier than 2001-01-01 | S2 | 2600h | 2600h | IMSLocal |  |  | Rel-7 |  |  |  |
| 199 | 68.2 | Delete - Stage 3 for IMS Local services |  | 151d? | 2004-11-10 | 2005-06-08 |  |  | 2004-11-10 | 2005-06-08 | 151d? | 407d | finish no earlier than 2005-06-08 | C1 | 1208h |  | IMSLocal | Keith Drage, Lucent | drage@lucent.com | Rel-7 |  |  |  |
| 200 | 69 | Deleted - IMS Phase 3 | milestone | 0d? | 2005-06-08 A | 2005-06-08 A | 100% |  | 2005-06-08 | 2005-06-08 | 0d? |  | finish no earlier than 2005-06-08 | S2 |  |  |  |  |  | Rel-7 |  |  |  |
| 201 | 70 | Deleted - Improvements of Radio Interface | milestone | 0d? | 2004-09-15 A | 2004-09-15 A | 100% |  | 2004-09-15 | 2004-09-15 | 0d? |  | start no earlier than 2004-09-15 | RP |  |  | RInImp |  | Rel-7 | Rel-7 | TSG | Cesar |  |

Notes:
- 190: Approved SA#27. BB Position in Work Plan to be confirmed
- 193: Moved from Rel6
- 198: DAB - Not yet required in SA2 as it exists in previous releases
- 201: Stage 2 description of Interim conclusion
